# WeldTestSched MV

Schedule from MS Project, 2007-06-25 to 2007-09-13.
pppl

## Calendars

- Standard: Mon-Fri 08:00-12:00, 13:00-17:00; Sat-Sun off. Exceptions (off unless hours are given): 2007-07-04.

## Resources

| Resource |
| --- |
| Mcole |
| M. Cole |
| E. Perry |
| M. Viola |
| M. Viola/R. Parsells |
| P. Heitz. |
| S. Raftopoulos |
| S. Jurz./R. Parsells |
| R. Elllis/R. Parsells |
| M. Viola/R. Ellis |
| S. Jurz. |
| R. Keilbach |
| S. Languish |
| T. Brown |
| J. Edwards |
| Zenex |
| L. Dudek |
| R. Ellis |
| R. Parsells |
| E. Perry/R. Ellis |
| R. Ellis/R. Parsells |
| S. Raftopoulos/R. Ellis |
| P. Heitz/R. Parsells/R. Ellis/M. Viola |

## Schedule

| ID | WBS | Task | Type | Duration | Start | Finish | Predecessors | Total slack | Free slack | Constraint | Resources | Work |
| --- | --- | --- | --- | --- | --- | --- | --- | --- | --- | --- | --- | --- |
| 1 | 1 | water jet cut A/B flange weld tests |  | 27.5d? | 2007-06-26 | 2007-08-03 |  | 29.5d |  |  |  |  |
| 2 | 2 | weld shim DXF files complete |  | 1d | 2007-06-28 | 2007-06-28 |  | 11d | 5d | start no earlier than 2007-06-28 | M. Cole | 8h |
| 3 | 3 | complete CAD model of weld test specimen |  | 1d? | 2007-07-06 | 2007-07-06 |  | 49d |  | start no earlier than 2007-07-06 | M. Cole | 8h |
| 4 | 4 | water jet cut shims for A/B flange weld test |  | 3d | 2007-07-09 | 2007-07-11 | 2 | 6d | 0d | finish no earlier than 2007-07-11 | E. Perry | 24h |
| 5 | 5 | solution anneal shims (note: these shims are not ground). |  | 1d | 2007-07-12 | 2007-07-12 | 4 | 27d | 1d | start no earlier than 2007-07-10 | S. Jurz. | 8h |
| 6 | 6 | assemble shims & flanges; grind reliefs in flanges |  | 3d | 2007-07-16 | 2007-07-18 | 5 | 26d | 0d | start no earlier than 2007-07-16 | J. Edwards | 24h |
| 7 | 7 | weld & monitor distortion; improvise clamping |  | 3d | 2007-07-19 | 2007-07-23 | 6 | 26d | 0d | start no earlier than 2007-07-05 | E. Perry/R. Ellis | 24h |
| 8 | 8 | analyze results at PPPL |  | 2d | 2007-07-24 | 2007-07-25 | 7 | 26d | 0d |  | R. Ellis/R. Parsells | 16h |
| 9 | 9 | analyze welds at EWI |  | 10d | 2007-07-26 | 2007-08-08 | 8 | 26d |  |  | P. Heitz. | 80h |
| 10 | 10 | Casting-Casting Weld Tests |  | 24d? | 2007-06-25 | 2007-07-27 |  | 34d |  | finish no earlier than 2007-07-27 |  |  |
| 11 | 11 | Mount A6 on angle plate |  | 1d? | 2007-06-25 | 2007-06-25 |  | 57d |  | start no earlier than 2007-06-25 | J. Edwards | 8h |
| 12 | 12 | Weld fiducials on A6 & B6 |  | 2d | 2007-07-10 | 2007-07-11 |  | 41d | 0d | start no earlier than 2007-07-10 | J. Edwards | 16h |
| 13 | 13 | Measure A6 casting |  | 2d | 2007-07-12 | 2007-07-13 | 12 | 31d | 0d | start no earlier than 2007-07-09 | S. Raftopoulos | 16h |
| 14 | 14 | Develop metrology plan |  | 7d | 2007-07-09 | 2007-07-17 | 13 | 42d |  | start no earlier than 2007-07-09 | R. Ellis | 56h |
| 15 | 15 | Remove A6 & lower & grout wedge |  | 4d | 2007-07-16 | 2007-07-19 | 13 | 31d | 0d | start no earlier than 2007-07-11 | J. Edwards | 32h |
| 16 | 16 | Re-mount A6 on wedge |  | 2d | 2007-07-20 | 2007-07-23 | 15 | 31d | 0d |  | J. Edwards | 16h |
| 17 | 18 | Re-measure A6 |  | 2d | 2007-07-24 | 2007-07-25 | 12, 16 | 31d | 0d |  | S. Raftopoulos | 16h |
| 18 | 17 | Measure B6 casting using A6 as base |  | 2d | 2007-07-26 | 2007-07-27 | 17, 16 | 31d | 0d |  | S. Raftopoulos | 16h |
| 19 | 19 | Complete CAD model for dimensional ref. |  | 3d? | 2007-07-30 | 2007-08-01 | 18, 17 | 31d |  | finish no earlier than 2007-07-12 | T. Brown | 24h |
| 20 | 20 | Prepare angle plate dogs & chocks |  | 4d | 2007-07-10 | 2007-07-13 |  | 44d |  | start no earlier than 2007-07-10 | J. Edwards | 32h |
| 21 | 21 | Water jet cut outboard 0,5" stk 316 SS shims |  | 4d | 2007-07-12 | 2007-07-17 | 4 | 6d | 0d | start no earlier than 2007-07-03 | E. Perry | 32h |
| 22 | 22 | Water jet cut inboard 0.625 316 SS |  | 3d | 2007-07-18 | 2007-07-20 | 21 | 6d | 0d |  | E. Perry | 24h |
| 23 | 23 | Assemble castings, align, torque & measure inbd. shims |  | 4d | 2007-07-23 | 2007-07-26 | 22 | 35d |  |  | J. Edwards | 32h |
| 24 | 24 | Purchase (2) grinding machines |  | 45d | 2007-07-13 | 2007-09-13 |  | 0d |  | start no earlier than 2007-07-13 | L. Dudek | 360h |
| 25 | 25 | Grind inbd. Shims to thickness (outside shop) |  | 4d | 2007-07-23 | 2007-07-26 | 22 | 6d | 0d |  | L. Dudek | 32h |
| 26 | 26 | Solution anneal shims |  | 2d | 2007-07-27 | 2007-07-30 | 25 | 6d | 1d |  | S. Jurz. | 16h |
| 27 | 27 | bushing drawings complete | milestone | 0d | 2007-07-02 | 2007-07-02 |  | 9d | 4d | start no earlier than 2007-07-02 | M. Cole |  |
| 28 | 28 | fabricate stock bushings |  | 5d | 2007-07-09 | 2007-07-13 | 27 | 44d |  | finish no earlier than 2007-07-13 | S. Languish | 40h |
| 29 | 29 | Zenex - fabricate eccentric bushings |  | 5d | 2007-07-09 | 2007-07-13 | 27 | 5d | 0d | start no earlier than 2007-07-09 | Zenex | 40h |
| 30 | 30 | align castings, Fit 25% stock bushings, 25% eccentric bushings & install |  | 7d | 2007-07-16 | 2007-07-24 | 29 | 5d | 0d |  | M. Viola | 56h |
| 31 | 31 | Weld procedure/weld qual. |  | 7d | 2007-07-09 | 2007-07-17 |  | 42d |  | start no earlier than 2007-07-09 | R. Keilbach | 56h |
| 32 | 32 | Purchase weld on strain gauges |  | 14d | 2007-07-09 | 2007-07-26 |  | 5d | 0d | start no earlier than 2007-07-09 | R. Parsells | 112h |
| 33 | 33 | Install strain gauges |  | 5d | 2007-07-27 | 2007-08-02 | 32 | 5d | 0d | start no earlier than 2007-07-11 | S. Jurz./R. Parsells | 40h |
| 34 | 34 | Set up dial ind., CMM, transit system |  | 5d | 2007-07-25 | 2007-07-31 | 30 | 5d | 0d | start no earlier than 2007-07-08 | R. Elllis/R. Parsells | 40h |
| 35 | 35 | Install all shims and bushings |  | 2d | 2007-08-01 | 2007-08-02 | 34, 26 | 5d | 0d |  | J. Edwards | 16h |
| 36 | 36 | Final align and baseline measurements |  | 3d | 2007-08-03 | 2007-08-07 | 35, 33 | 5d | 0d |  | S. Raftopoulos/R. Ellis | 24h |
| 37 | 37 | Perform 25% of welding & measure |  | 2d | 2007-08-08 | 2007-08-09 | 36 | 5d | 0d | start no earlier than 2007-07-09 | E. Perry/R. Ellis | 16h |
| 38 | 36 | Perform 50% of welding & measure |  | 2d | 2007-08-10 | 2007-08-13 | 37 | 5d | 0d |  | E. Perry/R. Ellis | 16h |
| 39 | 37 | Perform 75% of welding & measure |  | 2d | 2007-08-14 | 2007-08-15 | 38 | 5d | 0d |  | E. Perry/R. Ellis | 16h |
| 40 | 38 | finish welding & measure |  | 2d | 2007-08-16 | 2007-08-17 | 39 | 5d | 0d |  | E. Perry/R. Ellis | 16h |
| 41 | 41 | Analyse results; write report |  | 14d | 2007-08-20 | 2007-09-06 | 40 | 5d |  |  | P. Heitz/R. Parsells/R. Ellis/M. Viola | 112h |
